# Shallow May schedule

Schedule from MS Project, 2007-05-01 to 2007-05-17.
MBARI

## Calendars

- Standard: Mon-Fri 08:00-12:00, 13:00-17:00; Sat-Sun off.

## Schedule

| ID | WBS | Task | Duration | Start | Finish | Predecessors | Baseline start | Baseline finish | Baseline duration | Total slack | Free slack | Constraint |
| --- | --- | --- | --- | --- | --- | --- | --- | --- | --- | --- | --- | --- |
| 1 | 1 | **GG recovry** | 2d? | 2007-05-01 | 2007-05-02 |  | 2007-05-01 | 2007-05-02 | 2d? | 4.5d |  |  |
| 2 | 1.1 | Load Ship and prepare for | 1d? | 2007-05-01 | 2007-05-01 |  | 2007-05-01 | 2007-05-01 | 1d? | 4.5d | 0d |  |
| 3 | 1.2 | Recover GG | 1d? | 2007-05-02 | 2007-05-02 | 2 | 2007-05-02 | 2007-05-02 | 1d? | 11d |  |  |
| 4 | 1.3 | Unload ship | 1d? | 2007-05-02 | 2007-05-02 | 2 | 2007-05-02 | 2007-05-02 | 1d? | 11d |  | start no earlier than 2007-05-02 |
| 5 | 1.4 | First Assesment of insrtument state | 1d? | 2007-05-02 | 2007-05-02 | 2 | 2007-05-02 | 2007-05-02 | 1d? | 11d |  | start no earlier than 2007-05-02 |
| 6 | 1.5 | Unload Pucks | 1d? | 2007-05-02 | 2007-05-02 | 2 | 2007-05-02 | 2007-05-02 | 1d? | 4.5d | 0d |  |
| 7 | 1.6 | Assesment test | 1d? | 2007-05-02 | 2007-05-02 |  | 2007-05-02 | 2007-05-02 | 1d? | 11d |  | start no earlier than 2007-05-02 |
| 10 | 2 | **Fix GG** | 1.85d | 2007-05-03 | 2007-05-04 |  | 2007-05-03 | 2007-05-04 | 1.85d | 2.55d |  |  |
| 11 | 2.1 | Replace motor | 0.25d | 2007-05-03 | 2007-05-03 |  | 2007-05-03 | 2007-05-03 | 0.25d | 2.55d | 0d | start no earlier than 2007-05-03 |
| 12 | 2.2 | Cold test assembly | 0.5d | 2007-05-03 | 2007-05-03 | 11 | 2007-05-03 | 2007-05-03 | 0.5d | 2.55d | 0d | start no earlier than 2007-05-03 |
| 13 | 2.3 | Install into GG | 0.25d | 2007-05-03 | 2007-05-03 | 12 | 2007-05-03 | 2007-05-03 | 0.25d | 2.55d | 0d | start no earlier than 2007-05-03 |
| 14 | 2.4 | Calibrate GG | 0.6d | 2007-05-04 | 2007-05-04 | 13 | 2007-05-04 | 2007-05-04 | 0.6d | 2.55d | 0d |  |
| 15 | 2.5 | Shuffle puck | 0.25d | 2007-05-04 | 2007-05-04 | 14 | 2007-05-04 | 2007-05-04 | 0.25d | 2.55d | 0.05d |  |
| 17 | 3 | **Refurbish Battery Packs** | 1d? | 2007-05-09 | 2007-05-09 |  | 2007-05-09 | 2007-05-09 | 1d? | 1.5d | 0d |  |
| 18 | 3.1 | Unload and recylce used batteries | 1d? | 2007-05-09 | 2007-05-09 |  | 2007-05-09 | 2007-05-09 | 1d? | 1.5d |  | start no earlier than 2007-05-09 |
| 19 | 3.2 | Load new batteries | 1d? | 2007-05-09 | 2007-05-09 |  | 2007-05-09 | 2007-05-09 | 1d? | 1.5d |  | start no earlier than 2007-05-09 |
| 20 | 3.3 | Load test | 1d? | 2007-05-09 | 2007-05-09 |  | 2007-05-09 | 2007-05-09 | 1d? | 1.5d |  | start no earlier than 2007-05-09 |
| 21 | 3.4 | fill with oil | 1d? | 2007-05-09 | 2007-05-09 |  | 2007-05-09 | 2007-05-09 | 1d? | 1.5d |  | start no earlier than 2007-05-09 |
| 23 | 4 | Integration test and DA testing | 0.1d | 2007-05-04 | 2007-05-06 | 15 | 2007-05-04 | 2007-05-06 | 0.1d | 2.5d | 0d | finish no earlier than 2007-05-06 |
| 25 | 5 | **Reload Pucks** | 7d? | 2007-05-01 | 2007-05-09 |  | 2007-05-01 | 2007-05-09 | 7d? | 1.5d | 0d |  |
| 26 | 5.1 | Archive and store samples | 1d? | 2007-05-03 | 2007-05-03 | 6 | 2007-05-03 | 2007-05-03 | 1d? | 4.5d | 0d |  |
| 27 | 5.2 | Print new arrays | 1d? | 2007-05-01 | 2007-05-01 |  | 2007-05-01 | 2007-05-01 | 1d? | 7.5d |  |  |
| 28 | 5.3 | Clean all pucks | 1d? | 2007-05-04 | 2007-05-04 | 26 | 2007-05-04 | 2007-05-04 | 1d? | 4.5d |  |  |
| 29 | 5.4 | Load pucks with fresh filters | 1d? | 2007-05-09 | 2007-05-09 |  | 2007-05-09 | 2007-05-09 | 1d? | 1.5d |  | finish no earlier than 2007-05-09 |
| 31 | 6 | LLNL CDR | 1d? | 2007-05-04 | 2007-05-04 |  | 2007-05-04 | 2007-05-04 | 1d? | 9d |  | start no earlier than 2007-05-04 |

| ID | WBS | Task | Duration | Start | Finish | Predecessors | Baseline start | Baseline finish | Baseline duration | Total slack | Free slack | Constraint |
| --- | --- | --- | --- | --- | --- | --- | --- | --- | --- | --- | --- | --- |
| 33 | 7 | **Software update** | 6d? | 2007-05-01 | 2007-05-08 |  | 2007-05-01 | 2007-05-08 | 6d? | 2.5d | 1d |  |
| 34 | 7.1 | coding | 3d? | 2007-05-01 | 2007-05-03 |  | 2007-05-01 | 2007-05-03 | 3d? | 5.5d |  | finish no earlier than 2007-05-03 |
| 35 | 7.2 | Testing using NEO | 1d? | 2007-05-03 | 2007-05-03 |  | 2007-05-03 | 2007-05-03 | 1d? | 5.5d |  | start no earlier than 2007-05-03 |
| 36 | 7.3 | Integration and test on GG | 2d? | 2007-05-07 | 2007-05-08 | 23 | 2007-05-07 | 2007-05-08 | 2d? | 2.5d |  | finish no earlier than 2007-05-08 |
| 38 | 8 | **Integrate GPS** | 5d? | 2007-05-03 | 2007-05-09 |  | 2007-05-03 | 2007-05-09 | 5d? | 1.5d | 0d |  |
| 39 | 8.1 | Receive new Modem | 1d? | 2007-05-03 | 2007-05-03 |  | 2007-05-03 | 2007-05-03 | 1d? | 5.5d |  | finish no earlier than 2007-05-03 |
| 40 | 8.2 | Bench test Modem | 1d? | 2007-05-07 | 2007-05-07 |  | 2007-05-07 | 2007-05-07 | 1d? | 3.5d |  | start no earlier than 2007-05-07 |
| 41 | 8.3 | Bench test with Mooring power | 1d? | 2007-05-07 | 2007-05-07 |  | 2007-05-07 | 2007-05-07 | 1d? | 3.5d |  | start no earlier than 2007-05-07 |
| 42 | 8.4 | Confirm email functionality | 1d? | 2007-05-09 | 2007-05-09 |  | 2007-05-09 | 2007-05-09 | 1d? | 1.5d |  | start no earlier than 2007-05-09 |
| 44 | 9 | **Integrate Isus into morring** | 7d? | 2007-05-01 | 2007-05-09 |  | 2007-05-01 | 2007-05-09 | 7d? | 1.5d | 0d |  |
| 45 | 9.1 | Cableing | 1d? | 2007-05-07 | 2007-05-07 |  | 2007-05-07 | 2007-05-07 | 1d? | 3.5d |  | start no earlier than 2007-05-07 |
| 46 | 9.2 | Mooring mouting | 5d | 2007-05-01 | 2007-05-07 |  | 2007-05-01 | 2007-05-07 | 5d | 3.5d |  | start no earlier than 2007-05-01 |
| 47 | 9.3 | integration test | 1d? | 2007-05-09 | 2007-05-09 |  | 2007-05-09 | 2007-05-09 | 1d? | 1.5d |  | start no earlier than 2007-05-09 |
| 49 | 10 | **System Integrated testing** | 2d? | 2007-05-10 | 2007-05-13 | 38, 33, 25, 23, 17, 10, 44 | 2007-05-10 | 2007-05-13 | 2d? | 1.5d | 0d |  |
| 50 | 10.1 | Prep for Intergration test | 1d? | 2007-05-10 | 2007-05-10 |  | 2007-05-10 | 2007-05-10 | 1d? | 1.5d | 0d | start no earlier than 2007-05-10 |
| 51 | 10.2 | Integration test | 1d? | 2007-05-11 | 2007-05-13 | 50 | 2007-05-11 | 2007-05-13 | 1d? | 1.5d |  | finish no earlier than 2007-05-13 |
| 53 | 11 | **GG deployment** | 4d | 2007-05-14 | 2007-05-17 |  | 2007-05-14 | 2007-05-17 | 4d | 0d |  |  |
| 54 | 11.1 | Load Instrument | 0.5d | 2007-05-14 | 2007-05-14 | 49 | 2007-05-14 | 2007-05-14 | 0.5d | 1.5d | 0d | start no earlier than 2007-05-14 |
| 55 | 11.2 | Can Instrument | 0.25d | 2007-05-14 | 2007-05-14 | 54 | 2007-05-14 | 2007-05-14 | 0.25d | 1.5d | 0d | start no earlier than 2007-05-14 |
| 56 | 11.3 | Assemble mooring | 0.25d | 2007-05-14 | 2007-05-14 | 55 | 2007-05-14 | 2007-05-14 | 0.25d | 1.5d | 0d | start no earlier than 2007-05-14 |
| 57 | 11.4 | Post Can QC | 0.5d | 2007-05-15 | 2007-05-15 | 56 | 2007-05-15 | 2007-05-15 | 0.5d | 1.5d |  | start no earlier than 2007-05-14 |
| 58 | 11.5 | Load Ship | 0.13d | 2007-05-16 | 2007-05-16 |  | 2007-05-16 | 2007-05-16 | 0.13d | 0.87d |  | start no earlier than 2007-05-16 |
| 59 | 11.6 | Deploy GG | 1d | 2007-05-17 | 2007-05-17 | 58, 57 | 2007-05-17 | 2007-05-17 | 1d | 0d |  | start no earlier than 2007-05-17 |
